# CoastalProfilingFloat ver2-0

Schedule from MS Project, 2012-01-03 to 2014-11-11.

## Calendars

- Standard: Mon-Fri 08:00-12:00, 13:00-17:00; Sat-Sun off.

## Resources

| Resource |
| --- |
| Gene |
| ME Tech |
| Machine Shop |
| EE Tech |

## Schedule

| ID | WBS | Task | Type | Duration | Start | Finish | Predecessors | Total slack | Free slack | Constraint | Resources | Work |
| --- | --- | --- | --- | --- | --- | --- | --- | --- | --- | --- | --- | --- |
| 1 | 1 | **System Engineering** |  | 120d | 2012-01-03 | 2012-06-18 |  | 294.41d | 0d |  |  | 184h |
| 2 | 1.1 | Address permitting issues |  | 6mo | 2012-01-03 | 2012-06-18 |  | 294.41d |  |  | Gene [12.5%] | 120h |
| 3 | 1.2 | Science req'ts definition |  | 15d | 2012-01-03 | 2012-01-23 |  | 75d | 0d |  | Gene [20%] | 24h |
| 4 | 1.3 | Evaluate buoyancy engine options |  | 30d | 2012-01-24 | 2012-03-05 | 3 | 75d |  |  | Gene [16.7%] | 40h |
| 5 | 2 | Modeling |  | 180d | 2012-06-19 | 2013-02-25 | 1 | 473.77d |  |  |  |  |
| 6 | 3 | **Preliminary design** |  | 45d? | 2012-06-19 | 2012-08-20 | 1 | 289.41d | 0d |  |  | 320h |
| 7 | 3.1 | Preliminary Design |  | 40d | 2012-06-19 | 2012-08-13 |  | 294.41d |  |  | Gene [50%] | 160h |
| 8 | 3.2 | Buoyancy engine testing |  | 10d | 2012-06-19 | 2012-07-02 |  | 314.41d |  |  | ME Tech [50%] | 40h |
| 9 | 3.3 | EE Tech |  | 5d? | 2012-08-14 | 2012-08-20 | 7 | 289.41d |  |  | EE Tech | 40h |
| 10 | 3.4 | ME Tech |  | 10d? | 2012-07-03 | 2012-07-16 | 8 | 314.41d |  |  | ME Tech | 80h |
| 11 | 4 | PDR | milestone | 0d | 2012-08-20 | 2012-08-20 | 6 | 289.41d | 0d |  |  |  |
| 12 | 5 | GIS tracking system |  | 5d? | 2012-08-21 | 2012-08-27 | 11 | 289.41d | 0d |  | Gene | 40h |
| 13 | 6 | Final Design |  | 60d | 2012-08-28 | 2012-11-19 | 12 | 289.41d | 0d |  | Gene [50%] | 240h |
| 14 | 7 | CDR | milestone | 0d | 2012-11-19 | 2012-11-19 | 13 | 289.41d | 0d |  |  |  |
| 15 | 8 | **Machine Shop** |  | 150d? | 2012-11-20 | 2013-06-17 | 14 | 289.41d |  |  |  | 200h |
| 16 | 8.1 | Modify first float |  | 4w | 2012-11-20 | 2012-12-17 |  | 289.41d | 0d |  | Machine Shop [75%] | 120h |
| 17 | 8.2 | Additional modifications |  | 10d? | 2013-06-04 | 2013-06-17 | 16FS+6mo | 366d |  |  | Machine Shop | 80h |
| 18 | 9 | **Engr Deployment #1** |  | 46.59d | 2013-01-01 | 2013-03-06 | 16 | 279.41d | 0d | start no earlier than 2013-01-01 |  | 216h |
| 19 | 9.1 | Engr Deployment #1 ME |  | 46.59d | 2013-01-01 | 2013-03-06 |  | 279.41d |  |  | Gene [25%] | 88h |
| 20 | 9.2 | Engr Deployment #1 ME Tech |  | 6.19d | 2013-01-01 | 2013-01-09 |  | 319.81d |  |  | ME Tech | 48h |
| 21 | 9.3 | Engr Deployment #1 EE Tech |  | 10d | 2013-01-01 | 2013-01-14 |  | 316d |  |  | EE Tech | 80h |
| 22 | 10 | **Engr Refine - Redeploy** |  | 160d | 2013-03-06 | 2013-10-16 | 18 | 279.41d |  |  |  | 400h |
| 23 | 10.1 | Engr R-R ME |  | 160d | 2013-03-06 | 2013-10-16 |  | 279.41d |  |  | Gene [25%] | 320h |
| 24 | 10.2 | Engr R-R ME Tech |  | 20d | 2013-03-06 | 2013-04-03 |  | 419.41d |  |  | ME Tech [50%] | 80h |
| 25 | 11 | Science Deployment #1 |  | 25d | 2014-01-01 | 2014-02-04 |  | 0d |  | start no earlier than 2014-01-01 | Gene [46.7%] | 88h |

| ID | WBS | Task | Duration | Start | Finish | Predecessors | Total slack | Constraint | Resources | Work |
| --- | --- | --- | --- | --- | --- | --- | --- | --- | --- | --- |
| 26 | 12 | **Sci Refine - Redeploy** | 200d | 2014-02-05 | 2014-11-11 | 25 | 0d |  |  | 400h |
| 27 | 12.1 | Sci R-R ME | 200d | 2014-02-05 | 2014-11-11 |  | 0d |  | Gene [20%] | 320h |
| 28 | 12.2 | Sci R-R ME Tech | 60d | 2014-02-05 | 2014-04-29 |  | 140d |  | ME Tech [16.7%] | 80h |
| 29 | 13 | Technology transfer discussions | 5mo | 2014-04-01 | 2014-08-18 |  | 61d | start no earlier than 2014-04-01 | Gene [10%] | 80h |
